Schedule from MS Project, 2017-12-04 to 2018-03-23, A marks actual dates.

## Calendars

- Standard: Mon-Fri 08:00-12:00, 13:00-17:00; Sat-Sun off. Exceptions (off unless hours are given): 2017-12-25 to 2018-01-07 (Vancances hivers), 2018-01-13 08:00-12:00, 13:00-17:00.

## Resources

| Resource |
| --- |
| Aymeric BOUVARD |
| Jocelyn Tan |
| Alexandre SINTUREL |
| Romain ruffieux |
| Jean |

## Schedule

| ID | WBS | Task | Duration | Start | Finish | Predecessors | Complete | Remaining | Total slack | Free slack | Constraint | Work |
| --- | --- | --- | --- | --- | --- | --- | --- | --- | --- | --- | --- | --- |
| 1 | 1 | **Preparation YETS** | 2d | 2017-12-13 A | 2017-12-14 A |  | 100% |  |  |  |  |  |
| 2 | 1.1 | Enlevement de l'escalier passerelle 193-393 | 0.5d | 2017-12-13 A | 2017-12-13 A |  | 100% |  |  |  | start no earlier than 2017-12-13 |  |
| 3 | 1.2 | Suppression bloc de ventilations | 1d | 2017-12-13 A | 2017-12-13 A | 2SS | 100% |  |  |  | start no earlier than 2017-12-11 |  |
| 4 | 1.3 | Enlevement exposion aimants | 1d | 2017-12-13 A | 2017-12-13 A | 2SS | 100% |  |  |  | start no earlier than 2017-12-11 |  |
| 5 | 1.4 | Enlevement tapis de sol circuit de visite | 0.5d | 2017-12-14 A | 2017-12-14 A | 4 | 100% |  |  |  | start no earlier than 2017-12-11 |  |
| 6 | 1.5 | Retrait des barrieres cote pont roulant zone de visite | 0.5d | 2017-12-14 A | 2017-12-14 A | 5 | 100% |  |  |  | start no earlier than 2017-12-11 |  |
| 7 | 2 | **Consignation AD Ring** | 1d? | 2017-12-18 A | 2017-12-18 A | 1 | 100% |  |  |  |  |  |
| 8 | 2.1 | Consignation électrique | 1d? | 2017-12-18 A | 2017-12-18 A |  | 100% |  |  |  | start no earlier than 2017-12-18 |  |
| 9 | 3 | **EYETS 2016-2017** | 50d? | 2017-12-19 A | 2018-03-09 | 7 | 16% | 42.2d? | 0d |  |  | 24h |
| 10 | 3.1 | **EN-EA** | 40d | 2017-12-19 | 2018-02-23 |  |  |  | 10d |  |  |  |
| 11 | 3.1.1 | Nettoyage cable ligne 8000 | 40d | 2017-12-19 | 2018-02-23 |  |  |  | 10d |  |  |  |
| 12 | 3.2 | **MSC** | 50d? | 2017-12-19 A | 2018-03-09 |  | 18% | 40.86d? | 0d |  |  |  |
| 13 | 3.2.1 | **QDN55** | 49d? | 2017-12-20 A | 2018-03-09 |  | 13% | 42.53d? | 0d |  |  |  |
| 14 | 3.2.1.1 | Ouverture Blindage | 1d | 2018-01-08 A | 2018-01-08 A |  | 100% |  |  |  | start no earlier than 2018-01-08 |  |
| 15 | 3.2.1.2 | Déconnexion vide | 1d? | 2017-12-20 A | 2017-12-20 A | 90SS | 100% |  |  |  | start no earlier than 2017-01-06 |  |
| 16 | 3.2.1.3 | Déconnexion élec et Hyrdaulique | 1d? | 2017-12-20 A | 2017-12-20 A | 15SS | 100% |  |  |  |  |  |
| 17 | 3.2.1.4 | Enlèvement QDN55 | 1d | 2018-01-09 A | 2018-01-09 A | 15SS, 14 | 100% |  |  |  | start no earlier than 2017-12-01 |  |
| 18 | 3.2.1.5 | Transfert QDN55 au 867 | 1d? | 2018-01-09 A | 2018-01-09 A | 17SS | 100% |  |  |  |  |  |
| 19 | 3.2.1.6 | Remise en état QDN55 | 20d | 2018-01-10 A | 2018-02-05 | 18 | 10% | 18d | 4d | 0d |  |  |
| 20 | 3.2.1.7 | Transfert QDN55 au 193 | 1d? | 2018-02-06 | 2018-02-06 | 19 |  |  | 4d | 0d |  |  |
| 21 | 3.2.1.8 | Remise en place QDN55 dans AD Ring | 1d? | 2018-02-06 | 2018-02-06 | 20SS, 93SS |  |  | 3d | 0d |  |  |
| 22 | 3.2.1.9 | Alignement | 1d? | 2018-02-07 | 2018-02-07 | 21 |  |  | 4d | 0d |  |  |
| 23 | 3.2.1.10 | Reconnexion vide | 4d? | 2018-02-08 | 2018-02-13 | 22 |  |  | 4d | 0d | start no earlier than 2017-11-21 |  |
| 24 | 3.2.1.11 | Pump down Leak check | 3d | 2018-02-08 | 2018-02-12 | 23SS |  |  | 9d | 0d |  |  |
| 25 | 3.2.1.12 | Préparation Bakeout | 1d | 2018-02-19 | 2018-02-19 | 24, 99SS |  |  | 0d |  |  |  |
| 26 | 3.2.1.13 | Bake out | 14d | 2018-02-20 | 2018-03-09 | 25, 100SS |  |  | 0d |  | start no earlier than 2017-03-06 |  |
| 27 | 3.2.1.14 | Décablage Bakeout | 1d | 2018-03-09 | 2018-03-09 | 26FF |  |  | 0d |  |  |  |
| 28 | 3.2.1.15 | Fermeture Blindage | 1d? | 2018-02-13 | 2018-02-13 | 24 |  |  | 17d | 0d |  |  |
| 29 | 3.2.1.16 | Remise en place exposition visite | 1d? | 2018-02-14 | 2018-02-14 | 28 |  |  | 17d | 0d | start no earlier than 2017-03-30 |  |

| ID | WBS | Task | Duration | Start | Finish | Predecessors | Complete | Remaining | Total slack | Free slack | Constraint |
| --- | --- | --- | --- | --- | --- | --- | --- | --- | --- | --- | --- |
| 30 | 3.2.2 | **QFN56** | 49d? | 2017-12-20 A | 2018-03-09 |  | 16% | 41.31d? | 0d |  |  |
| 31 | 3.2.2.1 | Ouverture blindage | 1d | 2018-01-08 A | 2018-01-08 A | 14SS | 100% |  |  |  | start no earlier than 2017-01-11 |
| 32 | 3.2.2.2 | Déconnexion vide | 1d | 2017-12-20 A | 2017-12-20 A | 15SS | 100% |  |  |  | finish no earlier than 2017-01-13 |
| 33 | 3.2.2.3 | Déconnexion électrique et hydraulique | 1d? | 2017-12-20 A | 2017-12-20 A | 32SS | 100% |  |  |  | start no earlier than 2017-01-16 |
| 34 | 3.2.2.4 | Déconnexion equipement BI | 1d? | 2017-12-20 A | 2017-12-20 A | 33SS | 100% |  |  |  | start no earlier than 2017-01-13 |
| 35 | 3.2.2.5 | Enlèvement QDFN56 | 1d? | 2018-01-09 A | 2018-01-09 A | 31, 33SS, 34SS | 100% |  |  |  | start no earlier than 2017-01-16 |
| 36 | 3.2.2.6 | Transfert QDFN56 au 867 | 1d? | 2018-01-09 A | 2018-01-09 A | 18SS | 100% |  |  |  |  |
| 37 | 3.2.2.7 | Remise en état QDFN56 | 20d | 2018-01-10 A | 2018-02-05 | 36, 19SS | 10% | 18d | 4d | 0d |  |
| 38 | 3.2.2.8 | Transfert QDFN56 au 193 | 1d? | 2018-02-06 | 2018-02-06 | 37, 20SS |  |  | 8d | 0d |  |
| 39 | 3.2.2.9 | Remise en place QDFN56 dans AD Ring | 1d | 2018-02-06 | 2018-02-06 | 38SS, 21SS |  |  | 4d | 0d |  |
| 40 | 3.2.2.10 | Alignement | 1d? | 2018-02-07 | 2018-02-07 | 39 |  |  | 4d | 0d |  |
| 41 | 3.2.2.11 | Reconnexion vide | 1d? | 2018-02-08 | 2018-02-08 | 40 |  |  | 4d | 0d |  |
| 42 | 3.2.2.12 | Pump down leak check | 3d | 2018-02-08 | 2018-02-12 | 24SS, 41SS |  |  | 4d |  |  |
| 43 | 3.2.2.13 | Préparation bakeout | 1d | 2018-02-19 | 2018-02-19 | 25SS, 42 |  |  | 0d |  | start no earlier than 2017-01-05 |
| 44 | 3.2.2.14 | Bakeout | 14d | 2018-02-20 | 2018-03-09 | 26SS, 43 |  |  | 0d |  |  |
| 45 | 3.2.2.15 | Décablage Bakeout | 1d | 2018-03-09 | 2018-03-09 | 27SS, 44FF |  |  | 0d |  |  |
| 46 | 3.2.2.16 | Fermeture blindage | 1d? | 2018-02-13 | 2018-02-13 | 28SS |  |  | 22d | 0d |  |
| 47 | 3.2.2.17 | Remise en place exposition visite | 1d? | 2018-02-14 | 2018-02-14 | 46, 29SS |  |  | 22d | 0d | start no earlier than 2017-03-30 |
| 48 | 3.2.3 | **BHS52** | 50d? | 2017-12-19 A | 2018-03-09 |  | 25% | 37.28d? | 0d |  |  |
| 49 | 3.2.3.1 | Ouverture Blindage | 4d | 2017-12-19 A | 2017-12-22 A |  | 100% |  |  |  |  |
| 50 | 3.2.3.2 | Deconnexion vide | 1d? | 2017-12-20 A | 2017-12-20 A | 88SS | 100% |  |  |  |  |
| 51 | 3.2.3.3 | Deconnexion hydraulique et electrique | 1d? | 2017-12-20 A | 2017-12-20 A | 33SS | 100% |  |  |  |  |
| 52 | 3.2.3.4 | Enlevement BHS52 | 1d | 2017-12-21 A | 2017-12-21 A | 51, 50, 89 | 100% |  |  |  | start no earlier than 2017-12-19 |
| 53 | 3.2.3.5 | Transfert BHS52 au 867 | 1d? | 2017-12-21 A | 2017-12-21 A | 52SS | 100% |  |  |  |  |
| 54 | 3.2.3.6 | Remise en etat BHS52 | 25d | 2017-12-22 A | 2018-02-07 | 53 | 25% | 18.75d | 19d | 0d |  |
| 55 | 3.2.3.7 | Transfert BHS52 au 193 | 1d? | 2018-02-08 | 2018-02-08 | 54 |  |  | 19d | 3d |  |
| 56 | 3.2.3.8 | Remise en place BHS52 dans AD Ring | 1d? | 2018-02-13 | 2018-02-13 | 96SS, 55SS |  |  | 21d | 0d |  |
| 57 | 3.2.3.9 | Alignement | 1d? | 2018-02-14 | 2018-02-14 | 56 |  |  | 16d | 0d |  |
| 58 | 3.2.3.10 | Reconnexion vide | 1d? | 2018-02-15 | 2018-02-15 | 57 |  |  | 16d |  |  |
| 59 | 3.2.3.11 | Pump down leak check | 1d? | 2018-02-16 | 2018-02-16 | 98SS |  |  | 20d |  |  |
| 60 | 3.2.3.12 | Preparation bakeout | 1d? | 2018-02-19 | 2018-02-19 | 43SS |  |  | 14d |  |  |
| 61 | 3.2.3.13 | Bakeout | 14d | 2018-02-20 | 2018-03-09 | 44SS |  |  | 0d |  |  |
| 62 | 3.2.3.14 | Decablage Bakeout | 1d? | 2018-03-09 | 2018-03-09 | 45SS |  |  | 0d |  |  |
| 63 | 3.2.3.15 | Fermeture Blindage | 1d? | 2018-02-13 | 2018-02-13 | 46SS |  |  | 23d |  |  |
| 64 | 3.2.3.16 | Remise en place exposition visite | 1d? | 2018-02-14 | 2018-02-14 | 47SS |  |  | 22d |  |  |

| ID | WBS | Task | Duration | Start | Finish | Predecessors | Complete | Remaining | Baseline start | Baseline finish | Baseline duration | Total slack | Free slack | Constraint | Text1 | Text2 | Text6 | Text27 |
| --- | --- | --- | --- | --- | --- | --- | --- | --- | --- | --- | --- | --- | --- | --- | --- | --- | --- | --- |
| 65 | 3.3 | **STI** | 13d | 2018-01-08 A | 2018-01-23 |  | 23% | 10d |  |  |  | 33d |  |  |  |  |  |  |
| 66 | 3.3.1 | Remplacement Scraper SHV1305 | 3d | 2018-01-08 A | 2018-01-10 A |  | 100% |  |  |  |  |  |  | start no earlier than 2018-01-08 |  |  |  |  |
| 67 | 3.3.2 | Bakeout | 10d | 2018-01-11 | 2018-01-23 | 66 |  |  |  |  |  | 33d |  |  |  |  |  |  |
| 68 | 3.4 | **VSC** | 50d? | 2017-12-19 A | 2018-03-09 | 8 | 36% | 32d? |  |  |  | 0d |  |  |  |  |  |  |
| 69 | 3.4.1 | **AD Ring** | 50d? | 2017-12-19 A | 2018-03-09 |  | 36% | 32d? |  |  |  | 0d |  |  |  |  |  |  |
| 70 | 3.4.1.1 | **WORK IN AD RING + EXPERIMENTAL LINES for TE-VSC** | 50d? | 2017-12-19 A | 2018-03-09 |  | 36% | 32d? | 1999-12-13 | 2000-03-01 | 58d | 0d |  |  | 122 days |  |  |  |
| 71 | 3.4.1.1.1 | Check all VPS;VPI;VPGs;VGP | 1d? | 2017-12-19 A | 2017-12-19 A |  | 100% |  |  |  |  |  |  | start no earlier than 2017-12-14 |  |  |  |  |
| 72 | 3.4.1.1.2 | Check all VGI | 1d? | 2017-12-19 A | 2017-12-19 A |  | 100% |  |  |  |  |  |  | start no earlier than 2017-12-04 |  |  |  |  |
| 73 | 3.4.1.1.3 | Test of Local VGI power supplies | 1d? | 2017-12-19 A | 2017-12-19 A |  | 100% |  |  |  |  |  |  | start no earlier than 2017-12-19 |  |  |  |  |
| 74 | 3.4.1.1.4 | Global survey VPI connectors | 1d | 2018-01-08 | 2018-01-08 |  |  |  |  |  |  | 50d |  | start no earlier than 2018-01-08 |  |  |  |  |
| 75 | 3.4.1.1.5 | Install bakeout on VPI feedthrough | 1d? | 2018-01-15 | 2018-01-15 |  |  |  |  |  |  | 44d |  | start no earlier than 2018-01-15 |  |  |  |  |
| 76 | 7.9 | **Line 6000** | 36d | 2017-12-19 A | 2018-02-19 |  | 33% | 24d | 1999-12-03 | 2000-03-07 | 58d | 14d |  |  | 1 day |  |  |  |
| 77 | 3.4.1.1.6.1 | Vent the sector | 1d | 2017-12-19 A | 2017-12-19 A |  | 100% |  |  |  |  |  |  |  |  |  |  |  |
| 78 | 3.4.1.1.6.2 | Oil change of Primary pump line 6000 | 1d | 2018-01-08 | 2018-01-08 |  |  |  |  |  |  | 50d |  | start no earlier than 2018-01-08 |  |  |  |  |
| 79 | 3.4.1.1.6.3 | Pump down & leak detection | 1d | 2018-02-19 | 2018-02-19 |  |  |  |  |  |  | 19d |  | start no earlier than 2018-02-19 |  |  |  |  |
| 80 | 7.9 | **SECTOR1A** | 13d | 2017-12-19 A | 2018-01-17 |  | 13% | 11.38d | 1999-12-03 | 2000-03-07 | 58d | 37d |  |  | 1 day |  |  |  |
| 81 | 3.4.1.1.7.1 | RGA scan Septum 53 | 1d | 2017-12-19 | 2017-12-19 |  |  |  |  |  |  | 49d |  | start no earlier than 2017-12-18 |  | YES | YES | AS |
| 82 | 3.4.1.1.7.2 | Vent the sector | 1d | 2017-12-20 A | 2017-12-20 A | 81 | 100% |  |  |  |  |  |  |  |  |  |  |  |
| 83 | 3.4.1.1.7.3 | Exchange of the Pirani/Penning tee position 47 | 1d | 2018-01-17 | 2018-01-17 |  |  |  |  |  |  | 42d |  | start no earlier than 2018-01-17 |  |  |  |  |
| 84 | 3.4.1.1.7.4 | Installation of the pumping stations | 1d | 2018-01-09 | 2018-01-09 |  |  |  |  |  |  | 47d | 0d | start no earlier than 2018-01-09 |  |  |  |  |
| 85 | 3.4.1.1.7.5 | Inspection of sublimators filament, exchange of the position 47 | 2d | 2018-01-10 | 2018-01-11 | 84 |  |  |  |  |  | 42d |  |  |  |  |  |  |
| 86 | 3.4.1.1.7.6 | Replacement of the VPI 50 & 54 | 2d | 2018-01-15 | 2018-01-16 |  |  |  |  |  |  | 43d |  | start no earlier than 2018-01-15 |  |  |  |  |
| 87 | 3.4.1.1.8 | **Magnets group Sector 1A - support for TE-MSC** | 32d | 2017-12-20 A | 2018-02-14 |  | 33% | 21.33d |  |  |  | 17d |  |  |  |  |  |  |
| 88 | 3.4.1.1.8.1 | Disconnection of the BHS 52 vacuum chamber sector 1A side and injection vacuum chamber | 1d | 2017-12-20 A | 2017-12-20 A | 82SS | 100% |  |  |  |  |  |  |  |  |  |  |  |
| 89 | 3.4.1.1.8.2 | Cut the injection vacuum chamber inside BHS 52 | 1d | 2017-12-20 A | 2017-12-20 A | 82SS | 100% |  |  |  |  |  |  |  |  |  |  |  |
| 90 | 3.4.1.1.8.3 | Disconnection of the Quadrupoles QDN 55, QFN 56 | 2d | 2017-12-20 A | 2017-12-21 A | 82SS | 100% |  |  |  |  |  |  |  |  |  |  |  |
| 91 | 3.4.1.1.8.4 | Consolidation of VPI port QFW50 | 2d | 2018-01-10 A | 2018-01-11 |  | 50% | 1d |  |  |  | 40d | 0d | start no earlier than 2018-01-10 |  |  |  |  |
| 92 | 3.4.1.1.8.5 | Pump down of the partial sector 47 to 52 & leak detection | 2d | 2018-01-12 | 2018-01-13 | 91 |  |  |  |  |  | 40d |  |  |  |  |  |  |
| 93 | 3.4.1.1.8.6 | Reinstallation of the Quadrupoles QDN55, QFN56 | 2d | 2018-02-06 | 2018-02-07 |  |  |  |  |  |  | 1d | 0d | start no earlier than 2018-02-06 |  |  |  |  |
| 94 | 3.4.1.1.8.7 | Pump down of the partial sector 53 to 56 & leak detection | 2d | 2018-02-08 | 2018-02-09 | 93 |  |  |  |  |  | 1d | 0d |  |  |  |  |  |
| 95 | 3.4.1.1.8.8 | Reweld injection vacuum chamber inside BHS52 + leak test | 1d | 2018-02-12 | 2018-02-12 | 94 |  |  |  |  |  | 1d | 0d |  |  |  |  |  |
| 96 | 3.4.1.1.8.9 | Reinstallation of the BHS 52 with both vacuum chambers | 2d | 2018-02-13 | 2018-02-14 | 95 |  |  |  |  |  | 1d | 0d |  |  |  |  |  |

| ID | WBS | Task | Duration | Start | Finish | Predecessors | Complete | Baseline start | Baseline finish | Baseline duration | Total slack | Free slack | Constraint | Text1 | Text2 |
| --- | --- | --- | --- | --- | --- | --- | --- | --- | --- | --- | --- | --- | --- | --- | --- |
| 97 | 3.4.1.1.9 | **Septa group Sector 1A - support for TE-ABT** | 16d | 2018-02-16 A | 2018-03-09 A |  | 100% |  |  |  |  |  |  |  |  |
| 98 | 3.4.1.1.9.1 | Pump down of the complete sector & leak detection | 1d | 2018-02-16 A | 2018-02-16 A | 96 | 100% |  |  |  |  |  | start no earlier than 2018-02-16 |  |  |
| 99 | 3.4.1.1.9.2 | Preparation Bake out | 1d | 2018-02-19 A | 2018-02-19 A | 98, 130 | 100% |  |  |  |  |  |  |  |  |
| 100 | 3.4.1.1.9.3 | Bake out time | 14d | 2018-02-20 A | 2018-03-09 A | 99 | 100% |  |  |  |  |  |  |  |  |
| 101 | 3.4.1.1.9.4 | Bake out disconnection | 1d | 2018-03-09 A | 2018-03-09 A | 100FF | 100% |  |  |  |  |  |  |  |  |
| 102 | 3.4.1.1.10 | **SECTOR1B** | 1d? | 2017-12-19 | 2017-12-19 |  |  | 1999-12-02 | 2000-03-07 | 59d | 49d |  |  | 1 day |  |
| 103 | 3.4.1.1.10.1 | RGA scan Tank 04 | 1d? | 2017-12-19 | 2017-12-19 |  |  |  |  |  | 49d |  |  |  |  |
| 104 | 7.11 | **SECTOR2A** | 1d | 2018-01-29 | 2018-01-29 |  |  | 1999-12-13 | 2000-03-21 | 62d | 29d |  |  | 73 days |  |
| 105 | 3.4.1.1.11.1 | Inspection for Scrapper consolidation | 1d | 2018-01-29 | 2018-01-29 |  |  |  |  |  | 34d |  | start no earlier than 2018-01-29 |  |  |
| 106 | 7.12 | **SECTOR2B** | 9d? | 2018-01-22 | 2018-02-01 |  |  | 1999-12-03 | 2000-01-21 | 26d | 26d |  |  | 55 days |  |
| 107 | 3.4.1.1.12.1 | Consolidation of VPI port (only if BHN20 is out) | 1d? | 2018-02-01 | 2018-02-01 |  |  |  |  |  | 31d |  | start no earlier than 2018-02-01 |  |  |
| 108 | 3.4.1.1.12.2 | Warm up sector | 5d | 2018-01-22 | 2018-01-26 |  |  |  |  |  | 32d | 0d | start no earlier than 2018-01-22 |  |  |
| 109 | 3.4.1.1.12.3 | Service of the cryohead systems | 3d | 2018-01-29 | 2018-01-31 | 108 |  |  |  |  | 27d |  |  |  |  |
| 110 | 7.12 | **SECTOR3** | 1d? | 2018-02-01 | 2018-02-01 |  |  | 1999-12-03 | 2000-01-21 | 26d | 26d |  |  | 55 days |  |
| 111 | 3.4.1.1.13.1 | RGA scan 27 | 1d? | 2018-02-01 | 2018-02-01 |  |  |  |  |  | 31d |  | start no earlier than 2018-02-01 |  |  |
| 112 | 3.4.1.1.14 | **SECTOR4** | 17d? | 2018-01-12 | 2018-02-02 |  |  | 1999-12-14 | 2000-03-20 | 0d | 25d |  |  |  |  |
| 113 | 3.4.1.1.14.1 | Warm up sector | 5d | 2018-01-22 | 2018-01-26 |  |  |  |  |  | 30d | 0d | start no earlier than 2018-01-22 |  |  |
| 114 | 3.4.1.1.14.2 | Service of the cryohead systems | 3d | 2018-01-29 | 2018-01-31 | 113 |  |  |  |  | 25d | 0d |  |  |  |
| 115 | 3.4.1.1.14.3 | Cool down the sector | 2d | 2018-02-01 | 2018-02-02 | 114 |  |  |  |  | 25d |  |  |  | YES |
| 116 | 3.4.1.1.14.4 | Gas injection system 42 maintenance | 1d? | 2018-01-12 | 2018-01-12 |  |  |  |  |  | 46d |  | start no earlier than 2018-01-12 |  |  |
| 117 | 3.4.1.1.15 | **DE EXPERIMENTAL LINES** | 3d? | 2018-03-01 | 2018-03-05 |  |  | 2000-03-01 | 2000-03-06 | 0d | 4d |  |  |  |  |
| 118 | 3.4.1.1.15.1 | Vent with nitrogen sector DE1.RFQD | 1d? | 2018-03-01 | 2018-03-01 |  |  |  |  |  | 9d | 0d | start no earlier than 2018-03-01 |  |  |
| 119 | 3.4.1.1.15.2 | Replacement of the gauge DE1.RFQD.VGP01 | 1d | 2018-03-01 | 2018-03-01 | 118SS |  |  |  |  | 11d |  |  |  |  |
| 120 | 3.4.1.1.15.3 | Pump down and leak detection | 1d? | 2018-03-02 | 2018-03-02 | 118 |  |  |  |  | 4d | 0d |  |  |  |
| 121 | 3.4.1.1.15.4 | Service of primary pump fixed pumping station BASE experiment | 1d | 2018-03-05 | 2018-03-05 | 120 |  |  |  |  | 4d |  |  |  |  |

| ID | WBS | Task | Duration | Start | Finish | Predecessors | Total slack | Free slack | Constraint | Resources | Work |
| --- | --- | --- | --- | --- | --- | --- | --- | --- | --- | --- | --- |
| 122 | 3.5 | **BCCC** | 50d? | 2017-12-19 | 2018-03-09 |  | 0d |  |  |  |  |
| 123 | 3.5.1 | Installation of new controlled flow valve and insulation vacuum valve | 5d | 2017-12-19 | 2018-01-08 |  | 15d | 0d |  |  |  |
| 124 | 3.5.2 | Warm-up and purge cryostat | 5d | 2018-01-09 | 2018-01-13 | 123 | 15d | 0d |  |  |  |
| 125 | 3.5.3 | Pump insulation vacuum | 20d | 2018-01-15 | 2018-02-09 | 124 | 15d |  |  |  |  |
| 126 | 3.5.4 | Removal of cryocooler unit for cleaning | 1d? | 2018-01-15 | 2018-01-15 | 124 | 38d | 32d |  |  |  |
| 127 | 3.5.5 | Re-installation of cryocooler | 1d? | 2018-03-01 | 2018-03-01 | 126 | 6d |  | start no earlier than 2018-03-01 |  |  |
| 128 | 3.5.6 | Cool-down and refill | 5d | 2018-03-05 | 2018-03-09 | 125, 100FF | 0d |  |  |  |  |
| 129 | 3.6 | **CV** | 9d | 2018-02-12 | 2018-02-22 |  | 11d |  |  |  |  |
| 130 | 3.6.1 | Maintenance eau déminéralisée | 5d | 2018-02-12 | 2018-02-16 |  | 11d | 0d | start no earlier than 2018-02-12 |  |  |
| 131 | 3.6.2 | Maintenance eau dure | 4d | 2018-02-19 | 2018-02-22 | 130 | 11d |  | start no earlier than 2017-03-23 |  |  |
| 132 | 3.7 | **RF** | 40d | 2018-01-15 | 2018-03-09 |  | 0d |  |  |  |  |
| 133 | 3.7.1 | **ADC02** | 40d | 2018-01-15 | 2018-03-09 |  | 0d |  |  |  |  |
| 134 | 3.7.1.1 | Maintenance ADC02 | 10d | 2018-01-15 | 2018-01-26 | 137SS | 25d |  | start no earlier than 2017-03-20 |  |  |
| 135 | 3.7.1.2 | Power test | 5d | 2018-03-05 | 2018-03-09 | 134 | 0d |  | start no earlier than 2018-03-05 |  |  |
| 136 | 3.7.2 | **ADC10** | 40d | 2018-01-15 | 2018-03-09 |  | 0d |  |  |  |  |
| 137 | 3.7.2.1 | Maintenance ADC10 | 10d | 2018-01-15 | 2018-01-26 |  | 25d | 0d | start no earlier than 2018-01-15 |  |  |
| 138 | 3.7.2.2 | Test RF Tube TH116 | 5d | 2018-03-05 | 2018-03-09 | 135SS | 0d |  | start no earlier than 2018-03-05 |  |  |
| 139 | 3.8 | **EL** | 2d | 2018-01-13 | 2018-01-15 |  | 39d |  |  |  |  |
| 140 | 3.8.1 | Test AUG | 2d | 2018-01-13 | 2018-01-15 |  | 39d |  | start no earlier than 2018-01-13 |  |  |
| 141 | 3.9 | **Kickers** | 1d? | 2017-12-19 | 2017-12-19 |  | 49d |  |  |  |  |
| 142 | 3.9.1 | Maintenance generale | 1d? | 2017-12-19 | 2017-12-19 |  | 49d |  |  |  |  |
| 143 | 3.10 | **BI** | 16d | 2017-12-19 | 2018-01-22 |  | 34d |  |  |  | 24h |
| 144 | 3.10.1 | E-Cooler: Controle circuit de refroidissement | 1d | 2017-12-19 | 2017-12-19 | 8 | 49d |  | start no earlier than 2016-12-19 | Jean | 8h |
| 145 | 3.10.2 | Maintenance cartouche de resine | 2d | 2017-12-19 | 2017-12-20 |  | 48d |  | start no earlier than 2017-02-06 | Jean | 16h |
| 146 | 3.10.3 | Maintenance generale des BTV | 5d | 2018-01-16 | 2018-01-22 |  | 34d |  | start no earlier than 2018-01-16 |  |  |

| ID | WBS | Task | Duration | Start | Finish | Predecessors | Complete | Remaining | Total slack | Free slack | Constraint |
| --- | --- | --- | --- | --- | --- | --- | --- | --- | --- | --- | --- |
| 147 | 3.11 | **RP** | 4d | 2018-01-08 | 2018-01-11 |  |  |  | 42d |  |  |
| 148 | 3.11.1 | tests source PMIA604, PAXA604, PAXPT113 | 4d | 2018-01-08 | 2018-01-11 |  |  |  | 42d |  | start no earlier than 2018-01-03 |
| 149 | 3.12 | **ICS** | 1d? | 2018-02-28 | 2018-02-28 |  |  |  | 7d |  |  |
| 150 | 3.12.1 | Access point maintenance (machine closed 9:00-13:00) Acces VSC (8:00-9:00) | 1d? | 2018-02-28 | 2018-02-28 |  |  |  | 7d |  | start no earlier than 2018-02-28 |
| 151 | 4 | **Hardware tests** | 10d? | 2018-03-12 | 2018-03-23 | 9 |  |  | 0d |  |  |
| 152 | 4.1 | Hardware test | 10d | 2018-03-12 | 2018-03-23 |  |  |  | 0d |  | start no earlier than 2018-03-05 |
| 153 | 4.2 | **Kickers** | 3d | 2018-03-12 | 2018-03-14 |  |  |  | 7d |  |  |
| 154 | 4.2.1 | Test without acces | 3d | 2018-03-12 | 2018-03-14 |  |  |  | 7d |  |  |
| 155 | 4.3 | **RF** | 5d? | 2018-03-12 | 2018-03-16 |  |  |  | 5d |  |  |
| 156 | 4.3.1 | Test ADC10 | 5d | 2018-03-12 | 2018-03-16 |  |  |  | 5d | 0d |  |
| 157 | 4.3.2 | Test RF tube TH116 | 1d? | 2018-03-12 | 2018-03-12 | 156SS |  |  | 9d |  |  |
| 158 | 5 | **YETS ELENA** | 18.5d? | 2017-12-04 A | 2018-01-11 |  | 51% | 9.07d? | 52.5d |  |  |
| 159 | 5.1 | Check all VGP, VGI, VPI | 0.5d | 2017-12-04 A | 2017-12-04 A |  | 100% |  |  |  | start no earlier than 2017-12-04 |
| 160 | 5.2 | **E-Cooler** | 10d | 2017-12-11 A | 2017-12-22 A |  | 100% |  |  |  |  |
| 161 | 5.2.1 | Montage + Installation E-Cooler | 10d | 2017-12-11 A | 2017-12-22 A |  | 100% |  |  |  | start no earlier than 2017-12-11 |
| 162 | 5.3 | **LNS10-20** | 8d? | 2017-12-04 A | 2017-12-13 |  | 94% | 0.47d? | 63d |  |  |
| 163 | 5.3.1 | Vent with Nitrogen LNS10 & LNS20 sectors | 0.5d | 2017-12-04 A | 2017-12-04 A |  | 100% |  |  |  | start no earlier than 2017-12-04 |
| 164 | 5.3.2 | Change of the sector valve LNS.VVGSH.0006 | 1d | 2017-12-05 A | 2017-12-05 A | 163 | 100% |  |  |  | start no earlier than 2017-12-05 |
| 165 | 5.3.3 | Change Roughing valve LNA.VVR.VPGR.0005 | 1d | 2017-12-05 A | 2017-12-05 A | 164SS | 100% |  |  |  |  |
| 166 | 5.3.4 | Pump down Leak Check | 1d? | 2017-12-06 A | 2017-12-06 A | 165 | 100% |  |  |  |  |
| 167 | 5.3.5 | Bakeout installation | 1d? | 2017-12-07 A | 2017-12-07 A | 166 | 100% |  |  |  |  |
| 168 | 5.3.6 | Bakeout | 3d | 2017-12-08 A | 2017-12-12 A | 167 | 100% |  |  |  |  |
| 169 | 5.3.7 | Bakeout Removal | 1d? | 2017-12-13 A | 2017-12-13 | 168 | 50% | 0.5d? | 63d |  |  |
| 170 | 5.4 | **LNR 30-40-50** | 14d | 2017-12-04 A | 2017-12-21 |  | 57% | 6d | 57d |  |  |
| 171 | 5.4.1 | Installation of the neon trolley for venting LNR30-50 + Bakeout | 2d | 2017-12-04 A | 2017-12-05 A |  | 100% |  |  |  | start no earlier than 2017-12-04 |
| 172 | 5.4.2 | Installation of the Magix Box LNR40 | 0.5d | 2017-12-06 A | 2017-12-06 A | 171 | 100% |  |  |  |  |
| 173 | 5.4.3 | Vent with Nitrogen LNR40 & evaluation leak toghtness sector valve in the neighbourhood | 1d | 2017-12-06 A | 2017-12-07 A | 172 | 100% |  |  |  |  |
| 174 | 5.4.4 | Removal of the beam pipe | 0.5d | 2017-12-07 A | 2017-12-07 A | 173 | 100% |  |  |  |  |
| 175 | 5.4.5 | Installation of the ecooler | 2d | 2017-12-08 A | 2017-12-11 A | 174 | 100% |  |  |  |  |
| 176 | 5.4.6 | Pump down Leak Check | 1d | 2017-12-12 A | 2017-12-12 A | 175 | 100% |  |  |  |  |
| 177 | 5.4.7 | Bakeout installation | 1d | 2017-12-13 A | 2017-12-13 A | 176 | 100% |  |  |  |  |
| 178 | 5.4.8 | Bakeout | 5d | 2017-12-14 | 2017-12-20 | 177 |  |  | 57d | 0d |  |
| 179 | 5.4.9 | Pinch OFF pumping station disconnection | 0.5d | 2017-12-21 | 2017-12-21 | 178 |  |  | 57d | 0d |  |
| 180 | 5.4.10 | Bakeout removal | 0.5d | 2017-12-21 | 2017-12-21 | 179 |  |  | 57d |  |  |

| ID | WBS | Task | Duration | Start | Finish | Predecessors | Total slack | Free slack | Constraint |
| --- | --- | --- | --- | --- | --- | --- | --- | --- | --- |
| 181 | 5.5 | **LNE50** | 9d | 2017-12-11 | 2017-12-21 |  | 57d |  |  |
| 182 | 5.5.1 | vent with nitrogen LNE50 | 0.5d | 2017-12-11 | 2017-12-11 |  | 65.5d |  | start no earlier than 2017-12-11 |
| 183 | 5.5.2 | Removal of the beam pipe | 0.5d | 2017-12-12 | 2017-12-12 |  | 57d | 0d | start no earlier than 2017-12-12 |
| 184 | 5.5.3 | Installation LPU (Survey) + SEM grid | 2d | 2017-12-12 | 2017-12-14 | 183 | 57d | 0d |  |
| 185 | 5.5.4 | Pump down Leak check | 0.5d | 2017-12-14 | 2017-12-14 | 184 | 57d | 0d |  |
| 186 | 5.5.5 | Bakeout installation | 1d | 2017-12-15 | 2017-12-15 | 185 | 57d | 0d |  |
| 187 | 5.5.6 | Bakeout | 3d | 2017-12-18 | 2017-12-20 | 186 | 57d | 0d |  |
| 188 | 5.5.7 | Pinch OFF pumping station disconnection | 0.5d | 2017-12-21 | 2017-12-21 | 187 | 57d | 0d |  |
| 189 | 5.5.8 | Bakeout removal | 0.5d | 2017-12-21 | 2017-12-21 | 188 | 57d |  |  |
| 190 | 5.6 | **LNI-LNE** | 10.5d | 2017-12-14 | 2018-01-11 |  | 52.5d |  |  |
| 191 | 5.6.1 | Vent with nitrogen LNI-LNE | 0.5d | 2017-12-14 | 2017-12-14 |  | 52.5d | 0d | start no earlier than 2017-12-14 |
| 192 | 5.6.2 | Installation of 4 SEM Grids + Survey | 2d | 2017-12-14 | 2017-12-18 | 191 | 52.5d | 0d |  |
| 193 | 5.6.3 | Pump down and lLeak Check | 1d | 2017-12-18 | 2017-12-19 | 192 | 52.5d | 0d |  |
| 194 | 5.6.4 | Bakeout installation | 1.5d | 2017-12-19 | 2017-12-20 | 193 | 52.5d | 0d |  |
| 195 | 5.6.5 | Bakeout | 4d | 2017-12-21 | 2018-01-09 | 194 | 52.5d | 0d |  |
| 196 | 5.6.6 | Pinch OFF pumping station disconnection | 0.5d | 2018-01-10 | 2018-01-10 | 195 | 52.5d | 0d |  |
| 197 | 5.6.7 | Bakeout removal | 1d | 2018-01-10 | 2018-01-11 | 196 | 52.5d |  |  |
| 198 | 6 | **YETS Gbar** | 10d | 2018-01-15 | 2018-01-26 |  | 40d |  |  |
| 199 | 6.1 | Installation LINAC | 10d | 2018-01-15 | 2018-01-26 |  | 40d |  | start no earlier than 2018-01-15 |
